# LCLS Integration Schedule 1-18-05

Schedule from MS Project, 2004-10-06 to 2009-04-28.
Stanford Linear Accelerator Center

## Calendars

- Standard: Mon-Fri 08:00-12:00, 13:00-17:00; Sat-Sun off.

## Schedule

| ID | WBS | Task | Type | Duration | Start | Finish | Predecessors | Total slack | Free slack | Constraint |
| --- | --- | --- | --- | --- | --- | --- | --- | --- | --- | --- |
| 1 | 1 | **LCLS Installation & Integration R1; 1-18-05 R.M. Boyce** |  | 0d | 2004-10-06 | 2004-10-06 |  | 0d |  |  |
| 3 | 1.1 | **Injector System** |  | 467d | 2005-05-06 | 2007-02-19 |  | 231d |  |  |
| 4 | 1.1.1 | Sector 20 Building Construction |  | 238d | 2005-05-06 | 2006-04-04 |  | 284d | 0d | finish no earlier than 2006-04-04 |
| 5 | 1.1.2 | Sector 20 Building Beneficial Occupancy Date | milestone | 0d | 2006-04-04 | 2006-04-04 | 4 | 284d | 0d |  |
| 6 | 1.1.3 | Sector 20 cable plant subcontract |  | 60d | 2006-03-08 | 2006-05-30 | 5FS-20d | 284d | 0d |  |
| 7 | 1.1.4 | Install Laser hdwr in S20 building |  | 40d | 2006-05-31 | 2006-07-25 | 6, 5 | 345d | 0d |  |
| 8 | 1.1.5 | Install Laser PPS & Safety System |  | 30d | 2006-05-31 | 2006-07-11 | 4, 6, 5 | 355d | 10d |  |
| 9 | 1.1.6 | Ready to Operate Laser in S20 Bldg only | milestone | 0d | 2006-07-25 | 2006-07-25 | 8, 7 | 345d | 114d |  |
| 10 | 1.1.7 | Install Injector hardware in alcove tunnel (L02,L01, RF Gun) |  | 60d | 2006-05-31 | 2006-08-22 | 6, 13 | 284d | 0d |  |
| 11 | 1.1.8 | Install PPS doors & cabling for Injector |  | 20d | 2006-08-23 | 2006-09-19 | 6, 10 | 284d | 0d |  |
| 12 | 1.1.9 | Injector PPS checks |  | 15d | 2006-09-20 | 2006-10-10 | 11 | 284d | 53d |  |
| 13 | 1.1.10 | Install, align & grout pipes in Wall A & Wall B |  | 15d | 2005-10-03 | 2005-10-21 | 26SS | 441d | 157d |  |
| 14 | 1.1.11 | Install Injector waveguide in Linac tunnel |  | 30d | 2005-10-03 | 2005-11-11 | 26SS | 497d | 202d |  |
| 15 | 1.1.12 | Install cable trays in Linac tunnel |  | 30d | 2006-08-07 | 2006-09-15 | 27SS | 246d | 0d |  |
| 16 | 1.1.13 | Install vac pipe & magnets from Wall A to Linac |  | 30d | 2006-08-07 | 2006-09-15 | 27SS, 13 | 241d | 0d |  |
| 17 | 1.1.14 | Install Straight Ahead Beam Dump in Linac tunnel |  | 20d | 2006-09-18 | 2006-10-13 | 16 | 241d | 0d |  |
| 18 | 1.1.15 | Pull cables into Linac for Injector |  | 15d | 2006-09-18 | 2006-10-06 | 15 | 246d | 5d |  |
| 19 | 1.1.16 | Connect cables to Injector components in linac tunnel |  | 20d | 2006-10-16 | 2006-11-10 | 17, 18 | 241d | 0d |  |
| 20 | 1.1.17 | Connect RF waveguide & Laser pipes |  | 30d | 2006-08-23 | 2006-10-03 | 10, 14 | 295d | 64d |  |
| 21 | 1.1.18 | Complete cable plant to Injector components |  | 20d | 2006-11-13 | 2006-12-08 | 10, 19 | 241d | 10d |  |
| 22 | 1.1.19 | Certify Injector PPS |  | 6d | 2006-12-25 | 2007-01-01 | 12, 27, 21 | 231d | 0d |  |
| 23 | 1.1.20 | First beam in Injector (to straight ahead dump) | milestone | 0d | 2007-01-01 | 2007-01-01 | 20, 11, 12, 9, 27, 22 | 231d | 0d |  |
| 24 | 1.1.21 | Commissioning of Injector |  | 35d | 2007-01-02 | 2007-02-19 | 23 | 231d | 14d |  |
| 26 | 1.2 | FY05 SLAC Downtime |  | 30d | 2005-10-03 | 2005-11-11 |  | 0d |  | start no earlier than 2005-10-03 |
| 27 | 1.3 | FY06 SLAC Downtime |  | 100d | 2006-08-07 | 2006-12-22 |  | 231d | 0d | start no earlier than 2006-08-07 |
| 28 | 1.4 | FY07 SLAC Downtime |  | 60d | 2007-07-02 | 2007-09-21 |  | 157d | 0d | start no earlier than 2007-07-02 |
| 29 | 1.5 | FY08 SLAC Downtime |  | 60d | 2008-08-04 | 2008-10-24 |  | 0d |  | start no earlier than 2008-08-04 |

| ID | WBS | Task | Type | Duration | Start | Finish | Predecessors | Total slack | Free slack | Constraint |
| --- | --- | --- | --- | --- | --- | --- | --- | --- | --- | --- |
| 31 | 1.6 | **Linac System** |  | 465d | 2006-08-07 | 2008-05-16 |  | 157d |  |  |
| 32 | 1.6.1 | Install L1 System |  | 20d | 2006-08-07 | 2006-09-01 | 27SS | 297d | 0d |  |
| 33 | 1.6.2 | Install BC1 hardware in Linac tunnel |  | 20d | 2006-09-04 | 2006-09-29 | 27SS, 32 | 297d | 0d |  |
| 34 | 1.6.3 | Install L2 System |  | 15d | 2006-10-02 | 2006-10-20 | 33 | 297d | 0d |  |
| 35 | 1.6.4 | Install L3 System |  | 15d | 2006-10-23 | 2006-11-10 | 34 | 297d | 30d |  |
| 36 | 1.6.5 | PPS/BCS modifications |  | 5d | 2006-12-25 | 2006-12-29 | 35, 33, 27 | 267d | 50d |  |
| 37 | 1.6.6 | Beam to end of Linac |  | 80d | 2007-03-12 | 2007-07-02 | 24, 36, 27, 28SF | 217d | 60d |  |
| 38 | 1.6.7 | Install BC2 hardware in Linac tunnel |  | 10d | 2007-07-02 | 2007-07-13 | 28SS | 207d | 50d |  |
| 39 | 1.6.8 | Commissioning beam to end of Linac |  | 170d | 2007-09-24 | 2008-05-16 | 37, 38, 28 | 157d | 0d |  |
| 41 | 1.7 | LCLS Phase I complete (Injector thru Linac) | milestone | 0d | 2008-05-16 | 2008-05-16 | 39, 24 | 157d | 87d |  |
| 43 | 1.8 | **Beam Transport Hall** |  | 432d | 2006-06-05 | 2008-01-29 |  | 70d |  |  |
| 44 | 1.8.1 | FFTB Shutdown | milestone | 0d | 2006-06-05 | 2006-06-05 |  | 149d | 0d | start no earlier than 2006-06-05 |
| 45 | 1.8.2 | Remove FFTB components |  | 45d | 2006-06-05 | 2006-08-04 | 44 | 149d | 0d |  |
| 46 | 1.8.3 | Cut & remove FFTB cable plant |  | 30d | 2006-08-07 | 2006-09-15 | 45 | 149d | 79d |  |
| 47 | 1.8.4 | Research yard modifications & by-pass road construction |  | 120d | 2006-07-21 | 2007-01-04 |  | 70d | 0d | start no earlier than 2006-07-21 |
| 48 | 1.8.5 | FFTB demolition |  | 20d | 2007-01-05 | 2007-02-01 | 47, 46 | 70d | 0d |  |
| 49 | 1.8.6 | BTH conventional construction |  | 258d | 2007-02-02 | 2008-01-29 | 48 | 70d | 0d |  |
| 50 | 1.8.7 | BTH Beneficial Occupancy | milestone | 0d | 2008-01-29 | 2008-01-29 | 49 | 70d | 0d |  |
| 52 | 1.9 | **Linac To Undulator components** |  | 90d | 2008-01-30 | 2008-06-03 |  | 145d |  |  |
| 53 | 1.9.1 | Install LTU hardware |  | 90d | 2008-01-30 | 2008-06-03 | 50 | 145d | 75d |  |
| 55 | 1.10 | **Undulator Hall** |  | 331d | 2006-03-15 | 2007-06-20 |  | 229d |  |  |
| 56 | 1.10.1 | Undulator Hall construction |  | 331d | 2006-03-15 | 2007-06-20 |  | 229d | 0d | start no earlier than 2006-03-15 |
| 57 | 1.10.2 | Undulator hall beneficial occupancy | milestone | 0d | 2007-06-20 | 2007-06-20 | 56 | 229d | 159d |  |
| 59 | 1.11 | **Magnetic Measurement Facility** |  | 640d | 2005-06-08 | 2007-11-20 |  | 195d |  |  |
| 60 | 1.11.1 | MMF construction |  | 150d | 2005-06-08 | 2006-01-03 |  | 195d | 0d | start no earlier than 2005-06-08 |
| 61 | 1.11.2 | Undulator hall beneficial occupancy | milestone | 0d | 2006-01-03 | 2006-01-03 | 60 | 195d | 0d |  |
| 62 | 1.11.3 | Install equipment & prepare facility |  | 55d | 2006-01-04 | 2006-03-21 | 61 | 195d | 0d |  |
| 63 | 1.11.4 | Assemble and Measure Undulators |  | 435d | 2006-03-22 | 2007-11-20 | 62 | 195d | 0d |  |
| 64 | 1.11.5 | Undulator assembly and measurements Complete | milestone | 0d | 2007-11-20 | 2007-11-20 | 63 | 195d | 125d |  |

| ID | WBS | Task | Type | Duration | Start | Finish | Predecessors | Total slack | Free slack | Constraint |
| --- | --- | --- | --- | --- | --- | --- | --- | --- | --- | --- |
| 66 | 1.12 | **Undulator System** |  | 165d | 2008-01-30 | 2008-09-16 |  | 70d |  |  |
| 67 | 1.12.1 | Prepare tunnel for Undulator support system install |  | 30d | 2008-01-30 | 2008-03-11 | 57, 50 | 70d | 0d |  |
| 68 | 1.12.2 | Install Undulator support system |  | 25d | 2008-03-12 | 2008-04-15 | 67, 50 | 70d | 0d | start no earlier than 2007-12-03 |
| 69 | 1.12.3 | Install Undulators completed assemblies |  | 25d | 2008-05-14 | 2008-06-17 | 68FS+20d, 64 | 70d | 0d |  |
| 70 | 1.12.4 | Install alignment system, connect cables, align cradles |  | 65d | 2008-06-18 | 2008-09-16 | 69 | 70d | 0d |  |
| 72 | 1.13 | **Beam Dump Facility** |  | 616d | 2006-03-15 | 2008-07-23 |  | 109d |  |  |
| 73 | 1.13.1 | Beam Dump Facility construction |  | 357d | 2006-03-15 | 2007-07-26 |  | 318d | 0d | start no earlier than 2006-03-15 |
| 74 | 1.13.2 | Beam Dump Beneficial Occupancy | milestone | 0d | 2007-07-26 | 2007-07-26 | 73 | 318d | 209d |  |
| 75 | 1.13.3 | Install Beam Dump hardware |  | 50d | 2008-05-15 | 2008-07-23 | 74 | 109d | 39d | start no earlier than 2008-05-15 |
| 77 | 1.14 | **Front End Enclosure** |  | 815d | 2006-03-15 | 2009-04-28 |  | 0d |  |  |
| 78 | 1.14.1 | Front End Enclosure conventional construction |  | 400d | 2006-03-15 | 2007-09-25 |  | 0d |  | start no earlier than 2006-03-15 |
| 79 | 1.14.2 | Front End Enclosure Beneficial Occupancy | milestone | 0d | 2007-09-25 | 2007-09-25 | 78 | 0d |  |  |
| 80 | 1.14.3 | Install-leakcheck-test Slit/Collimator A |  | 115d | 2006-09-27 | 2007-03-06 |  | 145d |  | start no earlier than 2006-09-27 |
| 81 | 1.14.4 | Install FEE slit/collimator A hardware |  | 130d | 2007-09-26 | 2008-03-25 | 79, 80 | 0d |  | start no earlier than 2007-07-10 |
| 82 | 1.14.5 | Install Gas Attenuator/Masks/slit-collimator B - Test |  | 217d | 2008-03-26 | 2009-01-22 | 81 | 0d |  |  |
| 83 | 1.14.6 | Install FEE Diagnostic Tank, Ion Pumped tank, Test |  | 68d | 2009-01-23 | 2009-04-28 | 82 | 0d |  |  |
| 85 | 1.15 | **Near Experimental Hall** |  | 555d | 2006-03-15 | 2008-04-29 |  | 170d |  |  |
| 86 | 1.15.1 | Near Experimental Hall conventional construction |  | 320d | 2006-03-15 | 2007-06-05 |  | 170d | 0d | start no earlier than 2006-03-15 |
| 87 | 1.15.2 | Near Experimental Hall Beneficial Occupancy | milestone | 0d | 2007-06-05 | 2007-06-05 | 86 | 170d | 0d |  |
| 88 | 1.15.3 | Install NH vacuum hardware, stands - H1&H2, Test |  | 235d | 2007-06-06 | 2008-04-29 | 87 | 170d | 100d | start no earlier than 2007-04-18 |
| 90 | 1.16 | **X-Ray Transport & Diagnostics Hall** |  | 552d | 2006-04-26 | 2008-06-05 |  | 143d |  |  |
| 91 | 1.16.1 | X-Ray Transport & Diagnostics Hall conventional construction |  | 370d | 2006-04-26 | 2007-09-25 |  | 245d | 0d | start no earlier than 2006-04-26 |
| 92 | 1.16.2 | X-Ray Transport & Diagnosticsl Hall Beneficial Occupancy | milestone | 0d | 2007-09-25 | 2007-09-25 | 91 | 245d | 102d |  |
| 93 | 1.16.3 | Install Vacuum hardware in Tunnel Mech/Vac |  | 80d | 2008-02-15 | 2008-06-05 | 92 | 143d | 73d | start no earlier than 2008-02-15 |

| ID | WBS | Task | Type | Duration | Start | Finish | Predecessors | Total slack | Free slack | Constraint |
| --- | --- | --- | --- | --- | --- | --- | --- | --- | --- | --- |
| 95 | 1.17 | **Far Experimental Hall** |  | 606d | 2006-03-15 | 2008-07-09 |  | 119d |  |  |
| 96 | 1.17.1 | Far Experimental Hall conventional construction |  | 385d | 2006-03-15 | 2007-09-04 |  | 119d | 0d | start no earlier than 2006-03-15 |
| 97 | 1.17.2 | Far Experimental Hall Beneficial Occupancy | milestone | 0d | 2007-09-04 | 2007-09-04 | 96 | 119d | 0d |  |
| 98 | 1.17.3 | Install Far Hall Controls & Test |  | 127d | 2007-09-05 | 2008-02-28 | 97 | 119d | 0d | start no earlier than 2007-06-07 |
| 99 | 1.17.4 | Install Far Hal Mech/Vac hardware |  | 94d | 2008-02-29 | 2008-07-09 | 97, 98 | 119d | 49d | start no earlier than 2008-01-08 |
| 101 | 1.18 | PPS/BCS complete through Far Hall | milestone | 0d | 2008-09-16 | 2008-09-16 | 53, 70, 75, 79, 87, 93, 99, 88 | 70d | 0d |  |
| 103 | 1.19 | First Beam through Undulator | milestone | 0d | 2008-09-16 | 2008-09-16 | 101, 41 | 70d | 0d |  |
| 104 | 1.20 | Beam commissioning through Undulator |  | 90d | 2008-09-17 | 2009-01-20 | 103 | 70d | 0d |  |
| 105 | 1.21 | Beam to Far Hall | milestone | 0d | 2009-01-20 | 2009-01-20 | 104 | 70d |  |  |
| 107 | 1.22 | **Central Lab & Office Complex** |  | 490d | 2006-11-13 | 2008-09-26 |  | 152d |  |  |
| 108 | 1.22.1 | Central Lab & Office Complex conventional construction |  | 490d | 2006-11-13 | 2008-09-26 |  | 152d | 0d | start no earlier than 2006-11-13 |
| 109 | 1.22.2 | Central Lab & Office Complex Beneficial Occupancy | milestone | 0d | 2008-09-26 | 2008-09-26 | 108 | 152d |  |  |
| 110 | 1.23 | LCLS Project Complete | milestone | 0d | 2009-04-28 | 2009-04-28 | 105, 109, 83 | 0d |  |  |
